# Example - Annual SWAT Process Schedule 2-15-2019

Schedule from MS Project, 2018-12-03 to 2020-01-03.

## Calendars

- Standard: Mon-Fri 08:00-12:00, 13:00-17:00; Sat-Sun off.

## Schedule

| ID | Task | Type | Duration | Start | Finish | Predecessors | Total slack | Free slack | Constraint |
| --- | --- | --- | --- | --- | --- | --- | --- | --- | --- |
| 1 | SWAT Planning Meeting Activities | manual | 1d? | 2019-01-02 | 2019-01-02 |  |  |  |  |
| 2 | Early call for NEW Candidate Projects (to MPOs, Counties, Tribes, Public, and other stakeholders) | milestone | 0d | 2019-01-20 | 2019-01-20 |  | 95d | 0d | finish no earlier than 2019-01-20 |
| 3 | List Known Projects to be considered for the Work Program |  | 1w | 2019-01-21 | 2019-01-25 | 2 | 95d | 34d |  |
| 4 | Assign Project Evaluation tasks to staff | milestone | 0d | 2019-03-15 | 2019-03-15 | 3 | 61d | 0d | start no earlier than 2019-03-15 |
| 5 | Coordinate to collect Project Info, run ETDM Planning Screens, complete Scoping Form A, and prepare Work Program Schedules |  | 12w | 2019-03-15 | 2019-06-06 | 4 | 61d | 36d |  |
| 6 | Early call for LOPPs | milestone | 0d | 2018-12-03 | 2019-03-03 |  | 25d | 0d | finish no earlier than 2019-03-03 |
| 7 | Receive LOPPs |  | 13w | 2019-03-04 | 2019-05-31 | 6 | 25d | 0d |  |
| 8 | Managers filter "Candidate Projects" to a reasonably-sized list that also identifies any New Projects for consideration |  | 2w | 2019-06-03 | 2019-06-14 | 7 | 25d | 0d |  |
| 9 | Assign Newly-Listed Project Evalutation tasks to staff | milestone | 0d | 2019-06-14 | 2019-06-14 | 8 | 145d | 0d |  |
| 10 | Preshedule SWAT Planning Meeting(s) | milestone | 0d | 2019-06-17 | 2019-06-17 | 9 | 145d |  | start no earlier than 2019-06-17 |
| 11 | Coordinate to collect Project Info, run ETDM Planning Screens, complete Scoping Form A, and prepare Work Program Schedules |  | 6w | 2019-06-17 | 2019-07-26 | 4, 8 | 25d | 0d | start no earlier than 2019-03-11 |
| 12 | Assemble SWAT Planning Meeting Spreadsheet |  | 2w | 2019-07-29 | 2019-08-09 | 5, 8, 11 | 25d | 0d |  |
| 13 | Hold SWAT Planning Meeting(s) |  | 2w | 2019-08-12 | 2019-08-23 | 12 | 25d | 0d |  |
| 14 | SWAT Planning Meeting(s) complete | milestone | 0d | 2019-08-23 | 2019-08-23 | 13 | 25d | 0d |  |
| 15 | Compile Draft District Tentative Work Plan |  | 3w | 2019-08-26 | 2019-09-13 | 14 | 25d | 0d |  |
| 16 | Local govt, MPO, County coordination |  | 3w | 2019-09-16 | 2019-10-04 | 15 | 25d | 0d |  |
| 17 | District Public Hearing(s) |  | 8w | 2019-10-07 | 2019-11-29 | 16 | 25d | 0d |  |
| 18 | Submit District Tentative Work Plan to Central Office | milestone | 0d | 2019-11-29 | 2019-11-29 | 17 | 25d |  |  |
| 19 | SWAT Strategy Meeting Activities | manual | 1d? | 2019-01-02 | 2019-01-02 |  |  |  |  |
| 20 | Preschedule SWAT Strategy Meeting(s) | milestone | 0d | 2019-01-06 | 2019-01-06 |  | 25d | 0d | finish no earlier than 2019-01-06 |
| 21 | List projects in the Work Program that await PD&E (or a SWAT Kick-off Meeting) |  | 1w | 2019-01-07 | 2019-01-11 | 20 | 25d | 0d |  |
| 22 | Assign Strategy Meeting preparatory tasks to staff | milestone | 0d | 2019-01-14 | 2019-01-14 | 21 | 25d | 0d | start no earlier than 2019-01-14 |
| 23 | Coordinate to collect Project Info, complete Scoping Form B, and develop SWAT Strategy Schedules |  | 10w | 2019-01-14 | 2019-03-22 | 22 | 25d | 0d |  |
| 24 | Draft Tentative Work Plan is Published | milestone | 0d | 2019-02-19 | 2019-02-19 |  | 29d | 0d | start no earlier than 2019-02-19 |
| 25 | Complete any supplemental project-level preparation |  | 4w | 2019-02-19 | 2019-03-18 | 24 | 29d | 4d |  |
| 26 | Conduct SWAT Strategy Meeting(s) |  | 4w | 2019-03-25 | 2019-04-19 | 23, 24, 25 | 25d | 0d |  |
| 27 | SWAT Strategy Meeting(s) complete | milestone | 0d | 2019-04-19 | 2019-04-19 | 26 | 25d | 0d |  |
| 28 | Run ETDM Programming Screens as determined |  | 8mo | 2019-04-22 | 2019-11-29 | 27 | 25d |  |  |
| 29 | SWAT Kick-off Meetings (12-15 mos prior to PD&E) | manual | 1d? | 2019-01-02 | 2019-01-02 |  |  |  |  |
| 30 | Project A - Prepare & Conduct Kick-off Mtg |  | 10w | 2019-02-18 | 2019-04-26 |  | 180d |  | start no earlier than 2019-02-17 |
| 31 | Project B - Prepare & Conduct Kick-off Mtg |  | 10w | 2019-03-25 | 2019-05-31 |  | 155d |  | start no earlier than 2019-03-24 |
| 32 | Project C - Prepare & Conduct Kick-off Mtg |  | 10w | 2019-06-10 | 2019-08-16 |  | 100d |  | start no earlier than 2019-06-09 |
| 33 | Project D - Prepare & Conduct Kick-off Mtg |  | 10w | 2019-06-17 | 2019-08-23 |  | 95d |  | start no earlier than 2019-06-16 |
| 34 | Project E - Prepare & Conduct Kick-off Mtg |  | 10w | 2019-09-16 | 2019-11-22 |  | 30d |  | start no earlier than 2019-09-15 |
| 35 | Project F - Prepare & Conduct Kick-off Mtg |  | 10w | 2019-10-28 | 2020-01-03 |  | 0d |  | start no earlier than 2019-10-27 |
